# IUCAAMilestones

Schedule from MS Project, 2012-07-25 to 2013-12-24.
Microsoft

## Calendars

- Standard: Mon-Fri 08:00-12:00, 13:00-17:00; Sat-Sun off.

## Schedule

| ID | WBS | Task | Type | Duration | Start | Finish | Total slack |
| --- | --- | --- | --- | --- | --- | --- | --- |
| 1 | 1 | **Milestones** |  | 370d? | 2012-07-25 | 2013-12-24 | 0d |
| 2 | 1.1 | Accept Mechanical Packaging Document | manual | 122d | 2012-07-25 | 2013-01-10 |  |
| 3 | 1.2 | Accept Requirements/Testing Document | manual | 16d | 2013-03-14 | 2013-04-04 |  |
| 4 | 1.3 | Develop Work Breakdown Schedule | manual | 49d | 2013-02-04 | 2013-04-11 |  |
| 5 | 1.4 | Deliver Instructions on Waveform Generation | manual | 21d | 2013-03-28 | 2013-04-25 |  |
| 6 | 1.5 | Host Computer Interface Instructions Document | manual | 21d | 2013-03-28 | 2013-04-25 |  |
| 7 | 1.6 | Deliver prototype Clock Board to Caltech | manual | 34d | 2013-03-14 | 2013-04-30 |  |
| 8 | 1.7 | Test Data for Clock Board | manual | 11d | 2013-04-04 | 2013-04-18 |  |
| 9 | 1.8 | Test Data for Analog Board | manual | 16d | 2013-04-19 | 2013-05-10 |  |
| 10 | 1.9 | Deliver prototype Analog Board to Caltech | manual | 21d | 2013-04-19 | 2013-05-17 |  |
| 11 | 1.10 | Schematics for preliminary Second Generation (2G) Clock Board | manual | 11d | 2013-05-01 | 2013-05-15 |  |
| 12 | 1.11 | Schematics for preliminary 2G Analog Board | manual | 11d | 2013-05-08 | 2013-05-22 |  |
| 13 | 1.12 | Write up of preliminary 2G design Performance | manual | 11d | 2013-05-15 | 2013-05-29 |  |
| 14 | 1.13 | Preliminary Mechanical Packaging Drawings | manual | 16d | 2013-05-23 | 2013-06-13 |  |
| 15 | 1.14 | IFPAC PDR | manual | 1d | 2013-07-02 | 2013-07-02 |  |
| 16 | 1.15 | Schematics for 2G Clock Board | manual | 14d | 2013-07-02 | 2013-07-19 |  |
| 17 | 1.16 | Schematics for 2G Analog Board | manual | 14d | 2013-07-09 | 2013-07-26 |  |
| 18 | 1.17 | Write up of 2G Design Performance | manual | 19d | 2013-07-02 | 2013-07-26 |  |
| 19 | 1.18 | 2G Clock Board Manufacture | manual | 10d | 2013-07-29 | 2013-08-09 |  |
| 20 | 1.19 | 2G Analog Board Manufacture | manual | 10d | 2013-07-29 | 2013-08-09 |  |
| 21 | 1.20 | Test Data for 2 G Clock Board | manual | 10d | 2013-08-12 | 2013-08-23 |  |
| 22 | 1.21 | Test Data for 2 G Analog Board | manual | 10d | 2013-08-19 | 2013-08-30 |  |
| 23 | 1.22 | Deliver 2G Boards to Caltech | manual | 5d | 2013-09-02 | 2013-09-06 |  |
| 24 | 1.23 | Final Mechanical Packaging Drawings | manual | 15d | 2013-09-09 | 2013-09-27 |  |
| 25 | 1.24 | IFPAC FDR | manual | 1d | 2013-10-08 | 2013-10-08 |  |
| 26 | 1.25 | Schematics for Final Clock Board | manual | 8d | 2013-10-09 | 2013-10-18 |  |
| 27 | 1.26 | Schematics for Final Analog Board | manual | 8d | 2013-10-16 | 2013-10-25 |  |
| 28 | 1.27 | Write up of Final Design Performance | manual | 6d | 2013-10-18 | 2013-10-25 |  |
| 29 | 1.28 | FInal Clock Board Manufacture | manual | 9d | 2013-10-25 | 2013-11-06 |  |
| 30 | 1.29 | Final Analog Board Manufacture | manual | 10d | 2013-10-28 | 2013-11-08 |  |
| 31 | 1.30 | Test Data for Final Clock Board | manual | 6d | 2013-11-07 | 2013-11-14 |  |
| 32 | 1.31 | Test Data for Final Analog Board | manual | 6d | 2013-11-15 | 2013-11-22 |  |
| 33 | 1.32 | Begin Production of Controller Board Sets | manual | 22d | 2013-11-25 | 2013-12-24 |  |
